# Professional_WBS_120_Activities

Schedule from MS Project, 2026-01-03 to 2026-08-15, costs in ریال, A marks actual dates.

## Calendars

- Standard: Mon-Thu 08:00-12:00, 13:00-17:00; Fri off; Sat-Sun 08:00-12:00, 13:00-17:00.

## Schedule

| ID | WBS | Task | Type | Duration | Start | Finish | Predecessors | Complete | Remaining | Total slack | Free slack | Cost | Actual cost | Text16 |
| --- | --- | --- | --- | --- | --- | --- | --- | --- | --- | --- | --- | --- | --- | --- |
| 1 | 1 | **پروژه احداث نیروگاه گازسوز 2000 کیلووات (CAT CG170)** |  | 193d | 2026-01-03 A | 2026-08-15 |  | 67% | 62.84d | 0d |  | 1,114,801.4 | 1,083,158.1 |  |
| 2 | 1.1 | شروع | milestone | 0d | 2026-01-03 A | 2026-01-03 A |  | 100% |  |  |  |  |  |  |
| 3 | 1.2 | **تشریفات قرارداد (contract)** |  | 122d | 2026-01-03 A | 2026-05-24 A |  | 100% |  |  |  |  |  |  |
| 4 | 1.2.1 | تهیه اسناد مناقصه و برگزاری تشریفات مناقصه |  | 60d | 2026-01-03 A | 2026-03-12 A | 2 | 100% |  |  |  |  |  | شرکت افق تأمین انرژی پارس |
| 5 | 1.2.2 | مذاکرات قراردادی و انعقاد قرارداد با پیمانکار EPC |  | 26d | 2026-03-14 A | 2026-04-12 A | 4 | 100% |  |  |  |  |  | شرکت افق تأمین انرژی پارس |
| 6 | 1.2.3 | انعقاد قرارداد MC |  | 1d | 2026-05-24 A | 2026-05-24 A | 5FS+35d | 100% |  |  |  |  |  | شرکت افق تأمین انرژی پارس |
| 7 | 1.1 | **مهندسی و طراحی (Engineering)** |  | 43.4d | 2026-04-14 A | 2026-06-03 |  | 94% | 2.61d | 62.6d |  | 5,000 | 4,719 |  |
| 8 | 1.1.1 | **طراحی پایه (Basic Design)** |  | 43.4d | 2026-04-14 A | 2026-06-03 |  | 95% | 2.17d | 62.6d |  | 1,000 | 950 |  |
| 9 | 1.1.1.1 | تهیه نقشه های جانمایی (General Layout) |  | 5d | 2026-04-14 A | 2026-05-26 | 6 | 95% | 0.25d | 0.15d | 0d | 200 | 190 | تانیر |
| 10 | 1.1.1.2 | تهیه نمودارهای P&ID سیستم های مکانیک |  | 5d | 2026-04-18 A | 2026-05-27 | 9 | 95% | 0.25d | 2.3d | 0d | 200 | 190 | تانیر |
| 11 | 1.1.1.3 | **طراحی تک خطی دیاگرام های برقی (SLD)** |  | 36.4d | 2026-04-22 A | 2026-06-03 |  | 95% | 1.82d | 62.6d |  | 600 | 570 |  |
| 12 | 1.1.1.3.1 | آماده سازی برای طراحی تک خطی دیاگرام های برقی (SLD) |  | 6d | 2026-04-22 A | 2026-05-31 | 10 | 95% | 0.3d | 2.5d | 0d | 300 | 285 | تانیر |
| 13 | 1.1.1.3.2 | اجرای نهایی و بازرسی طراحی تک خطی دیاگرام های برقی (SLD) |  | 6d | 2026-04-26 A | 2026-06-03 | 12 | 95% | 0.3d | 62.6d |  | 300 | 285 | تانیر |
| 14 | 1.1.2 | **مهندسی تفصیلی (Detail Design)** |  | 36.9d | 2026-04-18 A | 2026-05-30 |  | 94% | 2.32d | 66.1d |  | 4,000 | 3,769 |  |
| 15 | 1.3.2.1 | **مهندسی عمران و سازه** |  | 35.4d | 2026-04-18 A | 2026-05-28 |  | 97% | 1.21d | 67.6d |  | 950 | 915 |  |
| 16 | 1.3.2.1.1 | **طراحی عمومی سایت** |  | 34.2d | 2026-04-18 A | 2026-05-27 |  | 95% | 1.71d | 0.05d |  | 150 | 142.5 |  |
| 17 | 1.3.2.1.1.1 | پلان کلی سایت (Plot Plan) |  | 1d | 2026-04-18 A | 2026-05-27 | 9 | 95% | 0.05d | 0.05d | 0d | 150 | 142.5 | تانیر |
| 18 | 1.3.2.1.2 | **طراحی فونداسیون‌ها** |  | 2d | 2026-04-19 A | 2026-04-20 |  | 99% | 0.02d | 100d |  | 250 | 247.5 |  |
| 19 | 1.3.2.1.2.1 | فونداسیون موتور |  | 1d | 2026-04-19 A | 2026-04-19 A | 17 | 100% |  |  |  | 50 | 50 | تانیر |
| 20 | 1.3.2.1.2.2 | فونداسیون ترانسفورماتور |  | 1d | 2026-04-20 A | 2026-04-20 A | 19 | 100% |  |  |  | 50 | 50 | تانیر |
| 21 | 1.3.2.1.2.3 | فونداسیون مخازن آب و روغن |  | 1d | 2026-04-20 A | 2026-04-20 A | 19 | 100% |  |  |  | 50 | 50 | تانیر |
| 22 | 1.3.2.1.2.4 | فونداسیون ایرکولر |  | 1d | 2026-04-20 A | 2026-04-20 | 19 | 95% | 0.05d | 100d |  | 50 | 47.5 | تانیر |
| 23 | 1.3.2.1.2.5 | فونداسیون پمپ‌ها |  | 1d | 2026-04-20 A | 2026-04-20 A | 19 | 100% |  |  |  | 50 | 50 | تانیر |
| 24 | 1.3.2.1.3 | **سیستم‌های زیرزمینی** |  | 33.4d | 2026-04-20 A | 2026-05-28 |  | 94% | 2.09d | 67.6d |  | 200 | 187.5 |  |
| 25 | 1.3.2.1.3.1 | طراحی کانال کابل |  | 1d | 2026-04-20 A | 2026-05-27 | 17 | 95% | 0.05d | 0.15d | 0d | 50 | 47.5 | تانیر |
| 26 | 1.3.2.1.3.2 | طراحی ترانشه لوله |  | 1d | 2026-04-21 A | 2026-05-27 | 25 | 95% | 0.05d | 0.15d | 0d | 50 | 47.5 | تانیر |
| 27 | 1.3.2.1.3.3 | طراحی پایپ اسلیپر |  | 1d | 2026-04-22 A | 2026-05-27 | 26 | 95% | 0.05d | 68.2d |  | 50 | 47.5 | تانیر |
| 28 | 1.3.2.1.3.4 | طراحی چاه‌های ارت |  | 1d | 2026-05-27 A | 2026-05-28 | 25 | 90% | 0.1d | 0.95d | 0d | 50 | 45 | تانیر |

| ID | WBS | Task | Duration | Start | Finish | Predecessors | Complete | Remaining | Total slack | Free slack | Cost | Actual cost | Text16 |
| --- | --- | --- | --- | --- | --- | --- | --- | --- | --- | --- | --- | --- | --- |
| 29 | 1.3.2.1.4 | **ساختمان‌ها و معماری** | 32.5d | 2026-04-20 A | 2026-05-27 |  | 95% | 1.62d | 68.5d |  | 200 | 190 |  |
| 30 | 1.3.2.1.4.1 | معماری سالن موتور | 1d | 2026-04-20 A | 2026-05-27 | 17 | 95% | 0.05d | 0.15d | 0d | 50 | 47.5 | تانیر |
| 31 | 1.3.2.1.4.2 | معماری شلتر (نما، مقطع، جزئیات) | 1d | 2026-04-21 A | 2026-05-27 | 30 | 95% | 0.05d | 68.5d |  | 50 | 47.5 | تانیر |
| 32 | 1.3.2.1.4.3 | ساختمان CCB / اتاق کنترل / سوئیچگی | 1d | 2026-04-21 A | 2026-05-27 | 30 | 95% | 0.05d | 0d |  | 100 | 95 | تانیر |
| 33 | 1.3.2.1.5 | **جزئیات سازه‌ای** | 3d | 2026-04-21 A | 2026-04-23 |  | 98% | 0.07d | 97d |  | 150 | 147.5 |  |
| 34 | 1.1.2.4 | نقشه سازه‌ای دودکش (Stack) | 1d | 2026-04-21 A | 2026-04-21 A | 30 | 100% |  |  |  | 50 | 50 | تانیر |
| 35 | 1.3.2.1.5.2 | سکوی رادیاتور | 2d | 2026-04-21 A | 2026-04-22 A | 22 | 100% |  |  |  | 50 | 50 | تانیر |
| 36 | 1.3.2.1.5.3 | سازه های نصب تجهیزات مکانیکی | 3d | 2026-04-21 A | 2026-04-23 | 23 | 95% | 0.15d | 97d |  | 50 | 47.5 | تانیر |
| 37 | 1.3.2.2 | **مهندسی مکانیک** | 30.7d | 2026-04-22 A | 2026-05-27 |  | 94% | 1.74d | 68.3d |  | 1,700 | 1,588 |  |
| 38 | 1.3.2.2.1 | **مبانی طراحی مکانیک** | 4d | 2026-04-22 A | 2026-04-26 A |  | 100% |  |  |  | 200 | 200 |  |
| 39 | 1.3.2.2.1.1 | شرح فرآیند | 2d | 2026-04-22 A | 2026-04-23 A | 10 | 100% |  |  |  | 100 | 100 | تانیر |
| 40 | 1.3.2.2.1.2 | معیارهای طراحی مکانیک | 2d | 2026-04-25 A | 2026-04-26 A | 39 | 100% |  |  |  | 100 | 100 | تانیر |
| 41 | 1.3.2.2.2 | **تجهیزات دوار** | 5d | 2026-04-27 A | 2026-05-02 |  | 90% | 0.5d | 90d |  | 350 | 300 |  |
| 42 | 1.3.2.2.2.1 | مشخصات و دیتاشیت موتورهای گازسوز | 1d | 2026-04-27 A | 2026-04-27 A | 40 | 100% |  |  |  | 50 | 50 | تانیر |
| 43 | 1.3.2.2.2.2 | **مهندسی و خرید پمپ‌ها** | 4d | 2026-04-28 A | 2026-05-02 |  | 88% | 0.5d | 90d |  | 300 | 250 |  |
| 44 | 1.3.2.2.2.2.1 | تهیه دیتاشیت پمپ LT Oil Feed | 1d | 2026-04-28 A | 2026-04-28 A | 42 | 100% |  |  |  | 50 | 50 |  |
| 45 | 1.3.2.2.2.2.2 | تهیه دیتاشیت پمپ HT Oil Feed | 1d | 2026-04-29 A | 2026-04-29 A | 44 | 100% |  |  |  | 50 | 50 |  |
| 46 | 1.3.2.2.2.2.3 | تهیه دیتاشیت پمپ Feed Water | 1d | 2026-04-30 A | 2026-04-30 A | 45 | 100% |  |  |  | 100 | 100 |  |
| 47 | 1.3.2.2.2.2.4 | تهیه دیتاشیت سایر پمپ‌ها (Utility / Service / Cooling) | 1d | 2026-05-02 A | 2026-05-02 | 46 | 50% | 0.5d | 90d |  | 100 | 50 |  |
| 48 | 1.3.2.2.3 | **تجهیزات ثابت** | 26.7d | 2026-04-27 A | 2026-05-27 |  | 98% | 0.67d | 68.3d |  | 150 | 147.5 |  |
| 49 | 1.3.2.2.3.1 | مشخصات مخازن | 1d | 2026-04-27 A | 2026-04-27 A | 40 | 100% |  |  |  | 100 | 100 | تانیر |
| 50 | 1.3.2.2.3.2 | سیستم تهویه و فن‌ها | 1d | 2026-04-27 A | 2026-05-27 | 30, 40 | 95% | 0.05d | 68.3d |  | 50 | 47.5 | تانیر |
| 51 | 1.3.2.2.4 | **مهندسی پایپینگ** | 4d | 2026-04-28 A | 2026-05-02 |  | 91% | 0.36d | 90d |  | 300 | 275 |  |
| 52 | 1.3.2.2.4.1 | نقشه‌های آرایش لوله (GA) | 1d | 2026-04-28 A | 2026-04-28 | 42 | 90% | 0.1d | 0.8d | 0d | 50 | 45 | تانیر |
| 53 | 1.3.2.2.4.2 | نقشه‌های ایزومتریک | 1d | 2026-04-29 A | 2026-04-29 | 52 | 80% | 0.2d | 0.95d | 0d | 50 | 40 | تانیر |
| 54 | 1.3.2.2.4.3 | نقشه‌های ساپورت لوله | 1d | 2026-04-30 A | 2026-04-30 | 53 | 95% | 0.05d | 91d |  | 100 | 95 | تانیر |
| 55 | 1.3.2.2.4.4 | متره و برآورد لوله‌ها (MTO) | 1d | 2026-04-30 A | 2026-04-30 | 53 | 95% | 0.05d | 0.95d | 0d | 50 | 47.5 | تانیر |
| 56 | 1.3.2.2.4.5 | عایق‌کاری و پوشش | 1d | 2026-05-02 A | 2026-05-02 | 55 | 95% | 0.05d | 90d |  | 50 | 47.5 | تانیر |

| ID | WBS | Task | Duration | Start | Finish | Predecessors | Complete | Remaining | Total slack | Free slack | Cost | Actual cost | Text16 |
| --- | --- | --- | --- | --- | --- | --- | --- | --- | --- | --- | --- | --- | --- |
| 57 | 1.3.2.2.5 | **سیستم‌های جانبی** | 2d | 2026-04-29 A | 2026-04-30 |  | 95% | 0.1d | 91d |  | 300 | 285 |  |
| 58 | 1.3.2.2.5.1 | سیستم خنک‌کاری | 1d | 2026-04-29 A | 2026-04-29 | 42, 52 | 95% | 0.05d | 0.95d | 0d | 50 | 47.5 | تانیر |
| 59 | 1.3.2.2.5.2 | سیستم روغن‌کاری | 1d | 2026-04-30 A | 2026-04-30 | 58 | 95% | 0.05d | 91d |  | 50 | 47.5 | تانیر |
| 60 | 1.3.2.2.5.3 | سیستم اگزاست | 1d | 2026-04-30 A | 2026-04-30 | 58 | 95% | 0.05d | 91d |  | 50 | 47.5 | تانیر |
| 61 | 1.3.2.2.5.4 | سیستم هوای سالن | 1d | 2026-04-30 A | 2026-04-30 | 58 | 95% | 0.05d | 91d |  | 150 | 142.5 | تانیر |
| 62 | 1.3.2.2.6 | **مهندسی فرآیند** | 4d | 2026-04-26 A | 2026-04-29 |  | 93% | 0.3d | 0.8d |  | 200 | 185 |  |
| 63 | 1.3.2.2.6.1 | **طراحی فرآیند** | 4d | 2026-04-26 A | 2026-04-29 |  | 93% | 0.3d | 0.8d |  | 200 | 185 |  |
| 64 | 1.3.2.2.6.1.1 | تهیه PFD | 1d | 2026-04-26 A | 2026-04-26 A |  | 100% |  |  |  | 50 | 50 | تانیر |
| 65 | 1.3.2.2.6.1.2 | تهیه P&ID | 1d | 2026-04-27 A | 2026-04-27 | 64 | 90% | 0.1d | 0.8d | 0d | 50 | 45 | تانیر |
| 66 | 1.3.2.2.6.1.3 | محاسبات هیدرولیکی | 1d | 2026-04-28 A | 2026-04-28 | 65 | 90% | 0.1d | 0.9d | 0d | 50 | 45 | تانیر |
| 67 | 1.3.2.2.6.1.4 | سایزینگ خطوط | 1d | 2026-04-29 A | 2026-04-29 | 66 | 90% | 0.1d | 0.8d | 0d | 50 | 45 | تانیر |
| 68 | 1.3.2.2.7 | **دیتاشیت‌ و اسپک** | 1d | 2026-04-30 A | 2026-04-30 |  | 98% | 0.02d | 91d |  | 150 | 147.5 |  |
| 69 | 1.3.2.2.7.1 | پمپ‌ها | 1d | 2026-04-30 A | 2026-04-30 A | 67 | 100% |  |  |  | 50 | 50 | تانیر |
| 70 | 1.3.2.2.7.2 | مولد | 1d | 2026-04-30 A | 2026-04-30 A | 67 | 100% |  |  |  | 50 | 50 | تانیر |
| 71 | 1.3.2.2.7.3 | سیستم خنک کاری (مولد و سالن) | 1d | 2026-04-30 A | 2026-04-30 | 67 | 95% | 0.05d | 91d |  | 50 | 47.5 | تانیر |
| 72 | 1.3.2.2.8 | **مستندات بهره‌برداری** | 1d | 2026-04-28 A | 2026-04-28 |  | 96% | 0.04d | 93d |  | 50 | 48 |  |
| 73 | 1.3.2.2.8.1 | دستورالعمل بهره‌برداری | 1d | 2026-04-28 A | 2026-04-28 | 65 | 96% | 0.04d | 93d |  | 50 | 48 | تانیر |
| 74 | 1.3.2.3 | **مهندسی برق** | 32.9d | 2026-04-22 A | 2026-05-30 |  | 95% | 1.65d | 66.1d |  | 1,240 | 1,176 |  |
| 75 | 1.3.2.3.1 | **سیستم قدرت** | 3.5d | 2026-05-03 A | 2026-05-06 |  | 95% | 0.17d | 86.5d |  | 300 | 285 |  |
| 76 | 1.3.2.3.1.1 | دیتا شیت و اسپک ترانسفورماتور قدرت | 2d | 2026-05-03 A | 2026-05-04 |  | 95% | 0.1d | 0.45d | 0d | 100 | 95 | تانیر |
| 77 | 1.3.2.3.1.2 | دیتا شیت و اسپک سوئیچگیر MV | 2d | 2026-05-04 A | 2026-05-06 | 76 | 95% | 0.1d | 0.15d | 0d | 100 | 95 | تانیر |
| 78 | 1.3.2.3.1.3 | AUX دیتا شیت و اسپک | 1d | 2026-05-04 A | 2026-05-05 | 76 | 95% | 0.05d | 0.45d | 0d | 50 | 47.5 | تانیر |
| 79 | 1.3.2.3.1.4 | تابلوهای توزیع LV دیتا شیت و اسپک | 1d | 2026-05-05 A | 2026-05-05 | 78 | 95% | 0.05d | 87d |  | 50 | 47.5 | تانیر |
| 80 | 1.3.2.3.2 | **مطالعات سیستم قدرت** | 4d | 2026-05-05 A | 2026-05-09 |  | 90% | 0.4d | 84d |  | 240 | 216 |  |
| 81 | 1.3.2.3.2.1 | مطالعات اتصال کوتاه | 2d | 2026-05-05 A | 2026-05-06 | 76 | 90% | 0.2d | 0.9d | 0d | 90 | 81 | تانیر |
| 82 | 1.3.2.3.2.2 | مطالعات پخش بار | 1d | 2026-05-07 A | 2026-05-07 | 81 | 90% | 0.1d | 0.9d | 0d | 50 | 45 | تانیر |
| 83 | 1.3.2.3.2.3 | مطالعات اتصال به شبکه | 1d | 2026-05-09 A | 2026-05-09 | 81, 82 | 90% | 0.1d | 84d |  | 100 | 90 | تانیر |

| ID | WBS | Task | Duration | Start | Finish | Predecessors | Complete | Remaining | Total slack | Free slack | Cost | Actual cost | Text16 |
| --- | --- | --- | --- | --- | --- | --- | --- | --- | --- | --- | --- | --- | --- |
| 84 | 1.3.2.3.3 | **کابل‌کشی** | 4d | 2026-05-03 A | 2026-05-06 |  | 98% | 0.1d | 86d |  | 200 | 195 |  |
| 85 | 1.3.2.3.3.1 | محاسبات سایز کابل | 1d | 2026-05-03 A | 2026-05-03 A |  | 100% |  |  |  | 50 | 50 | تانیر |
| 86 | 1.3.2.3.3.2 | لیست کابل‌ها | 1d | 2026-05-04 A | 2026-05-04 A | 85 | 100% |  |  |  | 50 | 50 | تانیر |
| 87 | 1.3.2.3.3.3 | طراحی سینی کابل | 1d | 2026-05-05 A | 2026-05-05 | 86 | 95% | 0.05d | 0.95d | 0d | 50 | 47.5 | تانیر |
| 88 | 1.3.2.3.3.4 | کابل‌ها (MTO) و سینی ها | 1d | 2026-05-06 A | 2026-05-06 | 86, 87 | 95% | 0.05d | 86d |  | 50 | 47.5 | تانیر |
| 89 | 1.3.2.3.4 | **ارت و روشنایی** | 32.4d | 2026-04-22 A | 2026-05-30 |  | 98% | 0.81d | 66.6d |  | 100 | 97.5 |  |
| 90 | 1.3.2.3.4.1 | طراحی سیستم ارتینگ | 1d | 2026-05-28 A | 2026-05-30 | 25, 28 | 95% | 0.05d | 66.6d |  | 50 | 47.5 | تانیر |
| 91 | 1.3.2.3.4.2 | طراحی روشنایی | 1d | 2026-04-22 A | 2026-04-22 A | 30, 32 | 100% |  |  |  | 50 | 50 | تانیر |
| 92 | 1.3.2.3.5 | **نقشه‌های برق** | 30.9d | 2026-04-22 A | 2026-05-27 |  | 96% | 1.16d | 68.1d |  | 200 | 192.5 |  |
| 93 | 1.3.2.3.5.1 | تک‌خطی MV و LV و AUX | 1d | 2026-05-05 A | 2026-05-06 | 77, 78 | 95% | 0.05d | 0.4d | 0d | 50 | 47.5 | تانیر |
| 94 | 1.3.2.3.5.2 | سیستم DC شارژر | 1d | 2026-05-06 A | 2026-05-07 | 93 | 95% | 0.05d | 85.8d |  | 50 | 47.5 | تانیر |
| 95 | 1.3.2.3.5.3 | پلان تجهیزات برق | 1d | 2026-04-22 A | 2026-05-27 | 32 | 95% | 0.05d | 0.95d | 0d | 50 | 47.5 | تانیر |
| 96 | 1.3.2.3.5.4 | آرایش تابلوها | 1d | 2026-04-23 A | 2026-04-23 A | 95 | 100% |  |  |  | 50 | 50 | تانیر |
| 97 | 1.3.2.3.6 | **سیستم اعلام و اطفاء حریق** | 27.9d | 2026-04-28 A | 2026-05-30 |  | 95% | 1.4d | 66.1d |  | 200 | 190 |  |
| 98 | 1.3.2.3.6.1 | دیاگرام بلوکی | 1d | 2026-04-28 A | 2026-04-28 | 65 | 95% | 0.05d | 0.95d | 0d | 50 | 47.5 | تانیر |
| 99 | 1.3.2.3.6.2 | دیاگرام لوپ | 1d | 2026-04-29 A | 2026-04-29 | 98 | 95% | 0.05d | 25.85d | 24.9d | 50 | 47.5 | تانیر |
| 100 | 1.3.2.3.6.3 | جانمایی تجهیزات | 1d | 2026-05-27 A | 2026-05-28 | 95 | 95% | 0.05d | 0.95d | 0d | 50 | 47.5 | تانیر |
| 101 | 1.3.2.3.6.4 | لیست تجهیزات | 1d | 2026-05-28 A | 2026-05-30 | 99, 100 | 95% | 0.05d | 66.1d |  | 50 | 47.5 | تانیر |
| 102 | 1.3.2.4 | **ابزار دقیق و کنترل (I&C)** | 30.7d | 2026-04-22 A | 2026-05-27 |  | 82% | 5.46d | 68.3d |  | 110 | 90 |  |
| 103 | 1.3.2.4.1 | **سیستم کنترل** | 3d | 2026-04-28 A | 2026-04-30 |  | 80% | 0.6d | 0.8d |  | 50 | 40 |  |
| 104 | 1.3.2.4.1.1 | فلسفه کنترل | 1d | 2026-04-28 A | 2026-04-28 | 65 | 80% | 0.2d | 0.8d | 0d | 20 | 16 | تانیر |
| 105 | 1.3.2.4.1.2 | لیست I/O | 1d | 2026-04-29 A | 2026-04-29 | 104 | 80% | 0.2d | 0.8d | 0d | 20 | 16 | تانیر |
| 106 | 1.3.2.4.1.3 | طراحی RTU | 1d | 2026-04-30 A | 2026-04-30 | 105 | 80% | 0.2d | 0.8d | 0d | 10 | 8 | تانیر |
| 107 | 1.3.2.4.2 | **ابزار دقیق** | 2d | 2026-04-30 A | 2026-05-02 |  | 80% | 0.4d | 90d |  | 30 | 24 |  |
| 108 | 1.3.2.4.2.1 | دیتاشیت ولوهای کنترلی | 1d | 2026-04-30 A | 2026-04-30 | 65, 67 | 80% | 0.2d | 91d |  | 10 | 8 | تانیر |
| 109 | 1.3.2.4.2.2 | لیست کابل‌های I&C | 1d | 2026-04-30 A | 2026-04-30 | 105 | 80% | 0.2d | 0.9d | 0d | 10 | 8 | تانیر |
| 110 | 1.3.2.4.2.3 | دیتاشیت تجهیزات خاص | 1d | 2026-05-02 A | 2026-05-02 | 106 | 80% | 0.2d | 90d |  | 10 | 8 | تانیر |

| ID | WBS | Task | Duration | Start | Finish | Predecessors | Complete | Remaining | Actual start | Actual finish | Total slack | Free slack | Cost | Actual cost | Text16 |
| --- | --- | --- | --- | --- | --- | --- | --- | --- | --- | --- | --- | --- | --- | --- | --- |
| 111 | 1.3.2.4.3 | **اتاق کنترل** | 30.7d | 2026-04-22 A | 2026-05-27 |  | 80% | 6.14d |  |  | 68.3d |  | 10 | 8 |  |
| 112 | 1.3.2.4.3.1 | طراحی اتاق کنترل | 1d | 2026-04-22 A | 2026-05-27 | 32 | 80% | 0.2d |  |  | 68.3d |  | 10 | 8 | تانیر |
| 113 | 1.3.2.4.4 | **یکپارچه‌سازی** | 5.2d | 2026-05-02 A | 2026-05-07 |  | 90% | 0.52d |  |  | 85.8d |  | 20 | 18 |  |
| 114 | 1.3.2.4.4.1 | متره کابل‌های I&C | 1d | 2026-05-02 A | 2026-05-02 | 109 | 90% | 0.1d |  |  | 90d |  | 10 | 9 | تانیر |
| 115 | 1.3.2.4.4.2 | ارتباط با برق | 1d | 2026-05-06 A | 2026-05-07 | 93, 106 | 90% | 0.1d |  |  | 85.8d |  | 10 | 9 | تانیر |
| 116 | 1.2 | **تأمین تجهیزات (Procurement)** | 147d | 2026-01-03 A | 2026-06-22 |  | 94% | 8.27d |  |  | 46d |  | 1,079,801.4 | 1,065,107.7 |  |
| 117 | 1.2.1 | **مولد گازسوز CAT CG170** | 48d | 2026-04-28 A | 2026-06-22 A |  | 100% |  |  |  |  |  | 946,400 | 946,400 |  |
| 118 | 1.2.1.1 | گشایش اعتبار و سفارش گذاری مولد | 25d | 2026-04-28 A | 2026-05-26 A | 42 | 100% |  |  |  |  |  | 236,600 | 236,600 | تانیر |
| 119 | 1.2.1.2 | فرآیند ساخت در کارخانه CAT | 17d | 2026-05-27 A | 2026-06-15 A | 118 | 100% |  |  |  |  |  | 236,600 | 236,600 | تانیر |
| 120 | 1.2.1.3 | **تست کارخانه ای (FAT) مولد و رادیاتور** | 1d | 2026-04-29 | 2026-04-30 | 119 | 100% |  | 2026-06-16 | 2026-06-22 |  |  | 236,600 | 236,600 |  |
| 121 | 1.2.1.3.1 | آماده سازی برای تست کارخانه ای (FAT) مولد و رادیاتور | 3d | 2026-06-16 A | 2026-06-18 A | 119 | 100% |  |  |  |  |  | 236,600 | 236,600 | تانیر |
| 122 | 1.2.1.3.2 | اجرای نهایی و بازرسی تست کارخانه ای (FAT) مولد و رادیاتور | 3d | 2026-06-20 A | 2026-06-22 A | 121 | 100% |  |  |  |  |  |  |  | تانیر |
| 123 | 1.2.1.4 | حمل بین المللی و ترخیص گمرکی | 6d | 2026-05-02 A | 2026-05-07 A | 120 | 100% |  |  |  |  |  | 236,600 | 236,600 | تانیر |
| 124 | 1.2.1.5 | تخلیه و انبارش در سایت | 1d | 2026-05-09 A | 2026-05-09 A | 123 | 100% |  |  |  |  |  |  |  | تانیر |
| 125 | 1.2.2 | **تجهیزات جانبی مولد (Tool kit/Batteries)** | 35d | 2026-04-28 A | 2026-06-07 |  | 90% | 3.5d |  |  | 59d |  | 4,422 | 3,979.8 |  |
| 126 | 1.2.2.1 | تأمین Tool Kit مخصوص کارخانه | 1d | 2026-04-28 A | 2026-04-28 | 42 | 90% | 0.1d |  |  | 93d |  | 1,000 | 900 | تانیر |
| 127 | 1.2.2.2 | تأمین باتری ها و شارژرها | 10d | 2026-05-27 A | 2026-06-07 | 118 | 90% | 1d |  |  | 59d |  | 2,600 | 2,340 | تانیر |
| 128 | 1.2.2.3 | تأمین متعلقات نصب و راه اندازی | 10d | 2026-05-27 A | 2026-06-07 | 118 | 90% | 1d |  |  | 59d |  | 822 | 739.8 | تانیر |
| 129 | 1.2.3 | **تأمین سیستم های مکانیکی** | 127d | 2026-01-03 A | 2026-05-30 |  | 90% | 13.07d |  |  | 66d |  | 54,792.9 | 47,374.38 |  |
| 130 | 1.2.3.1 | تأمین تجهیزات (داکت) ورودی هوای احتراق | 3d | 2026-05-02 A | 2026-05-04 A | 71 | 100% |  |  |  |  |  | 3,644.2 | 3,644.2 | تانیر |
| 131 | 1.2.3.2 | ساخت و تأمین اجزای دودکش و سایلنسر | 3d | 2026-05-05 A | 2026-05-07 | 130 | 90% | 0.3d |  |  | 0.1d | 0d | 9,631.1 | 8,667.99 | تانیر |
| 132 | 1.2.3.3 | تأمین لوله و اتصالات گاز (Gas Train) | 1d | 2026-05-09 A | 2026-05-09 | 131 | 10% | 0.9d |  |  | 0.85d | 0d | 3,644.2 | 364.42 | تانیر |
| 133 | 1.2.3.4 | تأمین کولر خنک کن هوایی (Radiator) | 1d | 2026-05-10 A | 2026-05-10 A | 132 | 100% |  |  |  |  |  | 3,904.5 | 3,904.5 | تانیر |
| 134 | 1.4.3.5 | تامین فن های ورودی / خروجی | 1d | 2026-01-03 A | 2026-01-03 A |  | 100% |  |  |  |  |  | 16,919.5 | 16,919.5 | تانیر |
| 135 | 1.4.3.6 | تامین عایق و رنگ | 1d | 2026-01-04 A | 2026-01-04 | 134 | 10% | 0.9d |  |  | 191d |  | 2,733.15 | 273.31 | تانیر |

| ID | WBS | Task | Duration | Start | Finish | Predecessors | Complete | Remaining | Total slack | Free slack | Cost | Actual cost | Text16 |
| --- | --- | --- | --- | --- | --- | --- | --- | --- | --- | --- | --- | --- | --- |
| 136 | 1.2.3.5 | **تأمین پمپ ها و تجهیزات روغنکاری** | 20d | 2026-05-03 A | 2026-05-25 |  | 95% | 1d | 0.9d | 0d | 14,316.25 | 13,600.45 |  |
| 137 | 1.4.3.7.1 | LT Oil Feed | 5d | 2026-05-03 A | 2026-05-07 A | 47 | 100% |  |  |  | 3,579.25 | 3,579.25 | تانیر |
| 138 | 1.4.3.7.2 | HT Oil Feed | 5d | 2026-05-09 A | 2026-05-13 A | 137 | 100% |  |  |  | 3,579 | 3,579 | تانیر |
| 139 | 1.4.3.7.3 | Feed Water | 5d | 2026-05-14 A | 2026-05-19 | 138 | 90% | 0.5d | 4.5d | 0d | 3,579 | 3,221.1 | تانیر |
| 140 | 1.4.3.7.4 | (Utility / Service / Cooling) | 5d | 2026-05-20 A | 2026-05-25 | 139 | 90% | 0.5d | 0.9d | 0d | 3,579 | 3,221.1 | تانیر |
| 141 | 1.2.3.6 | تأمین فن ها و دمپرهای تهویه سالن | 4d | 2026-05-26 A | 2026-05-30 | 136 | 90% | 0.4d | 66d |  |  |  | تانیر |
| 142 | 1.2.4 | **تأمین تجهیزات برقی و کنترل** | 13d | 2026-05-09 A | 2026-05-23 |  | 91% | 1.16d | 72d |  | 74,186.5 | 67,353.52 |  |
| 143 | 1.2.4.1 | ساخت تابلوهای مصرف داخلی (Aux) | 3d | 2026-05-09 A | 2026-05-11 |  | 90% | 0.3d | 2.7d | 0d | 6,507.5 | 5,856.75 | تانیر |
| 144 | 1.2.4.2 | تأمین سوئیچگیر MV | 3d | 2026-05-12 A | 2026-05-14 | 143 | 90% | 0.3d | 0.9d | 0d | 32,537.5 | 29,283.75 | تانیر |
| 145 | 1.2.4.3 | خرید کابل های MV و LV | 1d | 2026-05-16 A | 2026-05-16 | 144 | 90% | 0.1d | 0.9d | 0d | 7,809 | 7,028.1 | تانیر |
| 146 | 1.4.4.4 | سیستم زمین (ارتینگ ثانویه) | 1d | 2026-05-17 A | 2026-05-17 | 145 | 90% | 0.1d | 0.9d | 0d | 1,952.25 | 1,757.03 | تانیر |
| 147 | 1.2.4.4 | تأمین سینی کابل و کاندوئیت ها | 1d | 2026-05-17 A | 2026-05-17 | 145 | 90% | 0.1d | 0.9d | 0d | 2,603 | 2,342.7 | تانیر |
| 148 | 1.2.4.5 | تأمین تجهیزات ابزاردقیق و مانیتورینگ | 1d | 2026-05-18 A | 2026-05-18 | 147 | 90% | 0.1d | 3.8d | 0d | 9,110.5 | 8,199.45 | تانیر |
| 149 | 1.4.4.7 | تامین تابلو gcp | 1d | 2026-05-18 A | 2026-05-18 | 146 | 90% | 0.1d | 2.7d | 0d | 1 | 0.9 | تانیر |
| 150 | 1.4.4.8 | تأمین Bulk Material | 3d | 2026-05-19 A | 2026-05-21 | 149 | 90% | 0.3d | 73d |  | 1,952.25 | 1,757.03 | تانیر |
| 151 | 1.2.4.6 | تأمین سیستم Gas Detection | 4d | 2026-05-19 A | 2026-05-23 | 148 | 95% | 0.2d | 23.4d | 21d | 11,713.5 | 11,127.83 | تانیر |
| 152 | 1.3 | **عملیات اجرایی (Construction)** | 62d | 2026-04-25 A | 2026-07-05 |  | 95% | 3d | 0d |  | 14,000 | 13,289.4 |  |
| 153 | 1.3.1 | **عملیات سیویل و آماده سازی** | 50d | 2026-04-25 A | 2026-06-21 |  | 99% | 0.21d | 12d |  | 6,498 | 6,469.8 |  |
| 154 | 1.3.1.1 | **خاکبرداری و تسطیح محل نصب** | 26d | 2026-04-25 A | 2026-05-24 A |  | 100% |  |  |  | 282 | 282 |  |
| 155 | 1.3.1.1.1 | آماده سازی برای خاکبرداری و تسطیح محل نصب | 1d | 2026-04-25 A | 2026-04-25 A |  | 100% |  |  |  | 141 | 141 | شرکت تأمین آب و انرژی هرمز ابدال |
| 156 | 1.3.1.1.2 | اجرای نهایی و بازرسی خاکبرداری و تسطیح محل نصب | 1d | 2026-05-24 A | 2026-05-24 A | 155, 151 | 100% |  |  |  | 141 | 141 | شرکت تأمین آب و انرژی هرمز ابدال |
| 157 | 1.3.1.2 | **فونداسیون‌ها و سازه‌های تجهیزات خاص** | 23d | 2026-05-24 A | 2026-06-18 A |  | 100% |  |  |  | 4,806 | 4,806 |  |
| 158 | 1.3.1.2.1 | فونداسیون و سازه رادیاتور | 9d | 2026-05-25 A | 2026-06-03 A | 154, 151 | 100% |  |  |  | 1,413 | 1,413 | شرکت تأمین آب و انرژی هرمز ابدال |
| 159 | 1.5.1.2.2 | فونداسیون و سازه مافلر | 9d | 2026-05-24 A | 2026-06-02 A | 151 | 100% |  |  |  | 1,131 | 1,131 | شرکت تأمین آب و انرژی هرمز ابدال |
| 160 | 1.5.1.2.3 | فونداسیون مخزن آب میک‌آپ | 9d | 2026-06-01 A | 2026-06-10 A | 159, 151 | 100% |  |  |  | 1,131 | 1,131 | شرکت تأمین آب و انرژی هرمز ابدال |
| 161 | 1.5.1.2.4 | فونداسیون مخزن روغن ترانسفورماتور | 9d | 2026-06-09 A | 2026-06-18 A | 160, 151 | 100% |  |  |  | 1,131 | 1,131 | شرکت تأمین آب و انرژی هرمز ابدال |

| ID | WBS | Task | Duration | Start | Finish | Predecessors | Complete | Remaining | Total slack | Cost | Actual cost | Text16 |
| --- | --- | --- | --- | --- | --- | --- | --- | --- | --- | --- | --- | --- |
| 162 | 1.3.1.3 | **عملیات تخریب و اصلاح سازه موجود** | 21.5d | 2026-05-26 A | 2026-06-20 |  | 96% | 0.86d | 13.5d | 705 | 676.8 |  |
| 163 | 1.3.1.3.1 | بررسی وضعیت شلتر و سقف موجود | 1d | 2026-06-17 A | 2026-06-20 | 157, 151 | 90% | 0.1d | 13.5d | 141 | 126.9 | شرکت تأمین آب و انرژی هرمز ابدال |
| 164 | 1.5.1.3.2 | ایمن‌سازی و آماده‌سازی محل کار | 1d | 2026-05-26 A | 2026-05-26 | 140 | 90% | 0.1d | 34d | 141 | 126.9 | شرکت تأمین آب و انرژی هرمز ابدال |
| 165 | 1.5.1.3.3 | باز کردن و جمع‌آوری سقف شلتر موجود | 1d | 2026-05-27 A | 2026-05-27 A | 164, 151 | 100% |  |  | 141 | 141 | شرکت تأمین آب و انرژی هرمز ابدال |
| 166 | 1.5.1.3.4 | حمل و جمع‌آوری مصالح سقف قبلی | 1d | 2026-05-28 A | 2026-05-28 A | 165 | 100% |  |  | 141 | 141 | شرکت تأمین آب و انرژی هرمز ابدال |
| 167 | 1.5.1.3.5 | کنترل سازه و آماده‌سازی برای اجرای سقف جدید | 1d | 2026-05-30 A | 2026-05-30 A | 166 | 100% |  |  | 141 | 141 | شرکت تأمین آب و انرژی هرمز ابدال |
| 168 | 1.3.1.4 | **اجرای سقف جدید و اصلاح معماری** | 23d | 2026-05-26 A | 2026-06-21 A |  | 100% |  |  | 705 | 705 |  |
| 169 | 1.5.1.4.1 | اجرای سقف مسطح موقت | 1d | 2026-05-26 A | 2026-05-26 A | 140 | 100% |  |  | 141 | 141 | تانیر |
| 170 | 1.5.1.4.2 | اجرای سازه نگهدارنده سقف نهایی | 1d | 2026-05-30 A | 2026-05-30 A | 169, 166 | 100% |  |  | 141 | 141 | تانیر |
| 171 | 1.5.1.4.3 | نصب شلتر سقف نهایی | 1d | 2026-05-31 A | 2026-05-31 A | 170, 166 | 100% |  |  | 141 | 141 | تانیر |
| 172 | 1.3.1.4.1 | آب‌بندی و عایق‌کاری سقف | 1d | 2026-06-20 A | 2026-06-20 A | 157, 166 | 100% |  |  | 141 | 141 | تانیر |
| 173 | 1.3.1.4.2 | تست بارگذاری و کنترل سازه سقف | 1d | 2026-06-21 A | 2026-06-21 A | 172, 166 | 100% |  |  | 141 | 141 | تانیر |
| 174 | 1.3.2 | **نصب تجهیزات مکانیکی** | 41d | 2026-05-10 A | 2026-06-25 |  | 92% | 3.11d | 8d | 4,089 | 3,778.8 |  |
| 175 | 1.3.2.1 | **استقرار و تراز مولد روی فونداسیون** | 2d | 2026-06-17 A | 2026-06-18 A |  | 100% |  |  | 282 | 282 |  |
| 176 | 1.3.2.1.1 | آماده سازی برای استقرار و تراز مولد روی فونداسیون | 1d | 2026-06-17 A | 2026-06-17 A | 161 | 100% |  |  | 141 | 141 | تانیر |
| 177 | 1.3.2.1.2 | اجرای نهایی و بازرسی استقرار و تراز مولد روی فونداسیون | 1d | 2026-06-18 A | 2026-06-18 A | 176 | 100% |  |  | 141 | 141 | تانیر |
| 178 | 1.3.2.2 | **نصب رادیاتور و سیستم خنک کن** | 1d | 2026-06-20 A | 2026-06-20 A |  | 100% |  |  | 282 | 282 |  |
| 179 | 1.3.2.2.1 | آماده سازی برای نصب رادیاتور و سیستم خنک کن | 1d | 2026-06-20 A | 2026-06-20 A | 133, 175 | 100% |  |  | 141 | 141 | تانیر |
| 180 | 1.3.2.2.2 | اجرای نهایی و بازرسی نصب رادیاتور و سیستم خنک کن | 1d | 2026-06-20 A | 2026-06-20 A | 133, 175, 177 | 100% |  |  | 141 | 141 | تانیر |
| 181 | 1.3.2.3 | **نصب سیستم دودکش و سایلنسر** | 2d | 2026-06-20 A | 2026-06-21 A |  | 100% |  |  | 282 | 282 |  |
| 182 | 1.3.2.3.1 | آماده سازی برای نصب سیستم دودکش و سایلنسر | 1d | 2026-06-20 A | 2026-06-20 A | 131, 175, 177 | 100% |  |  | 141 | 141 | تانیر |
| 183 | 1.3.2.3.2 | اجرای نهایی و بازرسی نصب سیستم دودکش و سایلنسر | 1d | 2026-06-21 A | 2026-06-21 A | 182, 177 | 100% |  |  | 141 | 141 | تانیر |
| 184 | 1.5.2.4 | **اجرای پایپینگ مربوط به پمپ‌ها** | 22d | 2026-05-30 A | 2026-06-23 |  | 92% | 1.8d | 10d | 1,551 | 1,424.1 |  |
| 185 | 1.5.2.4.1 | **آماده‌سازی نصب** | 22d | 2026-05-30 A | 2026-06-23 A |  | 100% |  |  | 423 | 423 |  |
| 186 | 1.5.2.4.1.1 | تحویل فونداسیون پمپ‌ها از سیویل | 1d | 2026-05-30 A | 2026-05-30 A | 166 | 100% |  |  | 141 | 141 | تانیر |
| 187 | 1.5.2.4.1.2 | چک‌لیست تراز و انکر بولت‌ها | 1d | 2026-06-22 A | 2026-06-22 A | 186, 183 | 100% |  |  | 141 | 141 | تانیر |
| 188 | 1.5.2.4.1.3 | آماده‌سازی محل نصب | 1d | 2026-06-23 A | 2026-06-23 A | 187, 186 | 100% |  |  | 141 | 141 | تانیر |

| ID | WBS | Task | Duration | Start | Finish | Predecessors | Complete | Remaining | Total slack | Free slack | Cost | Actual cost | Text16 |
| --- | --- | --- | --- | --- | --- | --- | --- | --- | --- | --- | --- | --- | --- |
| 189 | 1.5.2.4.2 | **نصب مکانیکی پمپ‌ها** | 4d | 2026-05-31 A | 2026-06-03 |  | 93% | 0.3d | 0.8d | 0d | 564 | 521.7 |  |
| 190 | 1.5.2.4.2.1 | نصب پمپ LT Oil Feed | 1d | 2026-05-31 A | 2026-05-31 A | 186 | 100% |  |  |  | 141 | 141 | تانیر |
| 191 | 1.5.2.4.2.2 | نصب پمپ HT Oil Feed | 1d | 2026-06-01 A | 2026-06-01 A | 190, 186 | 100% |  |  |  | 141 | 141 | تانیر |
| 192 | 1.5.2.4.2.3 | نصب پمپ Feed Water | 1d | 2026-06-02 A | 2026-06-02 | 191, 186 | 85% | 0.15d | 0.85d | 0d | 141 | 119.85 | تانیر |
| 193 | 1.5.2.4.2.4 | نصب سایر پمپ‌ها | 1d | 2026-06-03 A | 2026-06-03 | 192, 186 | 85% | 0.15d | 0.8d |  | 141 | 119.85 | تانیر |
| 194 | 1.5.2.4.3 | **اجرای پایپینگ ورودی/خروجی پمپ‌ها** | 5d | 2026-06-04 A | 2026-06-09 |  | 85% | 0.75d | 22d |  | 564 | 479.4 |  |
| 195 | 1.5.2.4.3.1 | suction پمپ‌ها oil | 1d | 2026-06-04 A | 2026-06-04 | 189 | 80% | 0.2d | 0.8d | 0d | 141 | 112.8 | تانیر |
| 196 | 1.5.2.4.3.2 | discharge پمپ‌ها oil | 1d | 2026-06-06 A | 2026-06-06 | 195 | 80% | 0.2d | 1.9d | 1d | 141 | 112.8 | تانیر |
| 197 | 1.5.2.4.3.3 | نصب ولوها و استرینرها | 1d | 2026-06-08 A | 2026-06-08 | 196 | 90% | 0.1d | 0.9d | 0d | 141 | 126.9 | تانیر |
| 198 | 1.5.2.4.3.4 | نصب ساپورت‌های لوله | 1d | 2026-06-09 A | 2026-06-09 | 197 | 90% | 0.1d | 22d |  | 141 | 126.9 | تانیر |
| 199 | 1.3.2.4 | **اجرای پایپینگ گاز و Gas Train** | 2d | 2026-05-10 A | 2026-05-11 |  | 85% | 0.3d | 39.8d | 39d | 282 | 239.7 |  |
| 200 | 1.3.2.4.1 | آماده سازی برای اجرای پایپینگ گاز و Gas Train | 1d | 2026-05-10 A | 2026-05-10 | 132 | 85% | 0.15d | 0.85d | 0d | 141 | 119.85 | تانیر |
| 201 | 1.3.2.4.2 | اجرای نهایی و بازرسی اجرای پایپینگ گاز و Gas Train | 1d | 2026-05-11 A | 2026-05-11 | 200 | 85% | 0.15d | 39.8d |  | 141 | 119.85 | تانیر |
| 202 | 1.3.2.5 | **اجرای پایپینگ آب خنک کن** | 2d | 2026-06-21 A | 2026-06-22 |  | 90% | 0.2d | 3.9d | 3d | 282 | 253.8 |  |
| 203 | 1.3.2.5.1 | آماده سازی برای اجرای پایپینگ آب خنک کن | 1d | 2026-06-21 A | 2026-06-21 | 133, 178, 186 | 90% | 0.1d | 0.9d | 0d | 141 | 126.9 | تانیر |
| 204 | 1.3.2.5.2 | اجرای نهایی و بازرسی اجرای پایپینگ آب خنک کن | 1d | 2026-06-22 A | 2026-06-22 | 203, 186 | 90% | 0.1d | 3.9d |  | 141 | 126.9 | تانیر |
| 205 | 1.3.2.6 | **نصب سیستم های روغنکاری و مخازن** | 2d | 2026-05-31 A | 2026-06-01 |  | 90% | 0.2d | 29d |  | 282 | 253.8 |  |
| 206 | 1.3.2.6.1 | آماده سازی برای نصب سیستم های روغنکاری و مخازن | 1d | 2026-05-31 A | 2026-05-31 | 186 | 90% | 0.1d | 0.9d | 0d | 141 | 126.9 | تانیر |
| 207 | 1.3.2.6.2 | اجرای نهایی و بازرسی نصب سیستم های روغنکاری و مخازن | 1d | 2026-06-01 A | 2026-06-01 | 206 | 90% | 0.1d | 29d |  | 141 | 126.9 | تانیر |
| 208 | 1.3.2.7 | **نصب تجهیزات تهویه و فن های سالن** | 2d | 2026-05-31 A | 2026-06-01 |  | 90% | 0.2d | 29d |  | 282 | 253.8 |  |
| 209 | 1.3.2.7.1 | آماده سازی برای نصب تجهیزات تهویه و فن های سالن | 1d | 2026-05-31 A | 2026-05-31 | 186 | 90% | 0.1d | 0.9d | 0d | 141 | 126.9 | تانیر |
| 210 | 1.3.2.7.2 | اجرای نهایی و بازرسی نصب تجهیزات تهویه و فن های سالن | 1d | 2026-06-01 A | 2026-06-01 | 209 | 90% | 0.1d | 29d |  | 141 | 126.9 | تانیر |
| 211 | 1.3.2.8 | **عایق کاری لوله های داغ و اگزوز** | 2d | 2026-06-22 A | 2026-06-23 |  | 90% | 0.2d | 0.9d | 0d | 282 | 253.8 |  |
| 212 | 1.3.2.8.1 | آماده سازی برای عایق کاری لوله های داغ و اگزوز | 1d | 2026-06-22 A | 2026-06-22 | 181, 186 | 90% | 0.1d | 0.9d | 0d | 141 | 126.9 | تانیر |
| 213 | 1.3.2.8.2 | اجرای نهایی و بازرسی عایق کاری لوله های داغ و اگزوز | 1d | 2026-06-23 A | 2026-06-23 | 212, 186 | 90% | 0.1d | 0.9d |  | 141 | 126.9 | تانیر |

| ID | WBS | Task | Duration | Start | Finish | Predecessors | Complete | Remaining | Total slack | Free slack | Cost | Actual cost | Text16 |
| --- | --- | --- | --- | --- | --- | --- | --- | --- | --- | --- | --- | --- | --- |
| 214 | 1.3.2.9 | **رنگ آمیزی و پوشش نهایی تجهیزات** | 2d | 2026-06-24 A | 2026-06-25 |  | 90% | 0.2d | 0.8d |  | 282 | 253.8 |  |
| 215 | 1.3.2.9.1 | آماده سازی برای رنگ آمیزی و پوشش نهایی تجهیزات | 1d | 2026-06-24 A | 2026-06-24 | 211, 166 | 90% | 0.1d | 0.9d | 0d | 141 | 126.9 | تانیر |
| 216 | 1.3.2.9.2 | اجرای نهایی و بازرسی رنگ آمیزی و پوشش نهایی تجهیزات | 1d | 2026-06-25 A | 2026-06-25 | 215, 166 | 90% | 0.1d | 0.8d | 0d | 141 | 126.9 | تانیر |
| 217 | 1.3.3 | **اجرای سیستم های برقی** | 8d | 2026-06-27 A | 2026-07-05 |  | 89% | 0.85d | 0d |  | 2,822 | 2,525.7 |  |
| 218 | 1.3.3.1 | **اجرای شبکه زمین و ارتینگ ثانویه** | 2d | 2026-06-27 A | 2026-06-28 |  | 90% | 0.2d | 6d |  | 282 | 253.8 |  |
| 219 | 1.3.3.1.1 | آماده سازی برای اجرای شبکه زمین و ارتینگ ثانویه | 1d | 2026-06-27 A | 2026-06-27 | 216 | 90% | 0.1d | 0.9d | 0d | 141 | 126.9 | تانیر |
| 220 | 1.3.3.1.2 | اجرای نهایی و بازرسی اجرای شبکه زمین و ارتینگ ثانویه | 1d | 2026-06-28 A | 2026-06-28 | 219 | 90% | 0.1d | 6d |  | 141 | 126.9 | تانیر |
| 221 | 1.3.3.2 | **نصب سینی کابل و نردبان کابل** | 2d | 2026-06-27 A | 2026-06-28 |  | 90% | 0.2d | 0.9d | 0d | 282 | 253.8 |  |
| 222 | 1.3.3.2.1 | آماده سازی برای نصب سینی کابل و نردبان کابل | 1d | 2026-06-27 A | 2026-06-27 | 216 | 90% | 0.1d | 0.9d | 0d | 141 | 126.9 | تانیر |
| 223 | 1.3.3.2.2 | اجرای نهایی و بازرسی نصب سینی کابل و نردبان کابل | 1d | 2026-06-28 A | 2026-06-28 | 222 | 90% | 0.1d | 0.9d |  | 141 | 126.9 | تانیر |
| 224 | 1.3.3.3 | **نصب تابلوهای فشار متوسط (MV)** | 2d | 2026-06-27 A | 2026-06-28 |  | 90% | 0.2d | 6d |  | 282 | 253.8 |  |
| 225 | 1.3.3.3.1 | آماده سازی برای نصب تابلوهای فشار متوسط (MV) | 1d | 2026-06-27 A | 2026-06-27 | 216 | 90% | 0.1d | 0.9d | 0d | 141 | 126.9 | تانیر |
| 226 | 1.3.3.3.2 | اجرای نهایی و بازرسی نصب تابلوهای فشار متوسط (MV) | 1d | 2026-06-28 A | 2026-06-28 | 225 | 90% | 0.1d | 6d |  | 141 | 126.9 | تانیر |
| 227 | 1.3.3.4 | **نصب تابلوهای فشار ضعیف و مصرف داخلی** | 2d | 2026-06-27 A | 2026-06-28 |  | 90% | 0.2d | 0.9d |  | 848 | 763.2 |  |
| 228 | 1.3.3.4.1 | آماده سازی برای نصب تابلوهای فشار ضعیف و مصرف داخلی | 1d | 2026-06-27 A | 2026-06-27 | 143, 216 | 90% | 0.1d | 0.9d | 0d | 424 | 381.6 | تانیر |
| 229 | 1.3.3.4.2 | اجرای نهایی و بازرسی نصب تابلوهای فشار ضعیف و مصرف داخلی | 1d | 2026-06-28 A | 2026-06-28 | 228, 216 | 90% | 0.1d | 0.9d | 0d | 424 | 381.6 | تانیر |
| 230 | 1.3.3.5 | **کابل کشی قدرت (MV/LV)** | 4d | 2026-06-29 A | 2026-07-02 |  | 88% | 0.5d | 0.9d | 0d | 564 | 493.5 |  |
| 231 | 1.3.3.5.1 | آماده سازی برای کابل کشی قدرت (MV/LV) | 1d | 2026-06-29 A | 2026-06-29 | 229 | 90% | 0.1d | 0.8d | 0d | 141 | 126.9 | تانیر |
| 232 | 1.3.3.5.2 | اجرای نهایی و بازرسی کابل کشی قدرت (MV/LV) | 1d | 2026-06-30 A | 2026-06-30 | 231 | 80% | 0.2d | 0.9d | 0d | 141 | 112.8 | تانیر |
| 233 | 1.5.3.5.3 | آماده سازی برای کابل کشی aux | 1d | 2026-07-01 A | 2026-07-01 | 232 | 90% | 0.1d | 0.9d | 0d | 141 | 126.9 | تانیر |
| 234 | 1.5.3.5.4 | اجرای نهایی و بازرسی کابل کشی aux | 1d | 2026-07-02 A | 2026-07-02 | 233 | 90% | 0.1d | 0.9d |  | 141 | 126.9 | تانیر |
| 235 | 1.3.3.6 | **کابل کشی کنترل و ابزاردقیق** | 2d | 2026-06-29 A | 2026-06-30 |  | 90% | 0.2d | 2.9d | 2d | 282 | 253.8 |  |
| 236 | 1.3.3.6.1 | آماده سازی برای کابل کشی کنترل و ابزاردقیق | 1d | 2026-06-29 A | 2026-06-29 | 221, 145, 229 | 90% | 0.1d | 0.9d | 0d | 141 | 126.9 | تانیر |
| 237 | 1.3.3.6.2 | اجرای نهایی و بازرسی کابل کشی کنترل و ابزاردقیق | 1d | 2026-06-30 A | 2026-06-30 | 236, 229 | 90% | 0.1d | 2.9d |  | 141 | 126.9 | تانیر |

| ID | WBS | Task | Type | Duration | Start | Finish | Predecessors | Complete | Remaining | Total slack | Free slack | Cost | Actual cost | Text16 |
| --- | --- | --- | --- | --- | --- | --- | --- | --- | --- | --- | --- | --- | --- | --- |
| 238 | 1.3.3.7 | **سربندی (Termination) کابل ها** |  | 2d | 2026-07-04 A | 2026-07-05 |  | 90% | 0.2d | 0d |  | 282 | 253.8 |  |
| 239 | 1.3.3.7.1 | آماده سازی برای سربندی (Termination) کابل ها |  | 1d | 2026-07-04 A | 2026-07-04 | 230, 235, 229 | 90% | 0.1d | 0.9d | 0d | 141 | 126.9 | تانیر |
| 240 | 1.3.3.7.2 | اجرای نهایی و بازرسی سربندی (Termination) کابل ها |  | 1d | 2026-07-05 A | 2026-07-05 | 239, 229 | 90% | 0.1d | 0d |  | 141 | 126.9 | تانیر |
| 241 | 1.3.4 | **نصب ابزاردقیق و کنترل** |  | 1d | 2026-06-27 A | 2026-06-27 |  | 85% | 0.15d | 7d |  | 591 | 515.1 |  |
| 242 | 1.3.4.1 | **نصب تجهیزات مانیتورینگ موتور** |  | 1d | 2026-06-27 A | 2026-06-27 |  | 90% | 0.1d | 7d |  | 282 | 253.8 |  |
| 243 | 1.3.4.1.1 | آماده سازی برای نصب تجهیزات مانیتورینگ موتور |  | 1d | 2026-06-27 A | 2026-06-27 | 175, 216 | 90% | 0.1d | 7d | 0d | 141 | 126.9 | تانیر |
| 244 | 1.3.4.1.2 | اجرای نهایی و بازرسی نصب تجهیزات مانیتورینگ موتور | milestone | 0d | 2026-06-27 A | 2026-06-27 | 243, 216 | 90% | 0d | 7d |  | 141 | 126.9 | تانیر |
| 245 | 1.3.4.2 | **نصب سنسورها و تجهیزات فیلد** |  | 1d | 2026-06-27 A | 2026-06-27 |  | 90% | 0.1d | 7d |  | 141 | 126.9 |  |
| 246 | 1.3.4.2.1 | آماده سازی برای نصب سنسورها و تجهیزات فیلد |  | 1d | 2026-06-27 A | 2026-06-27 | 199, 202, 216 | 90% | 0.1d | 7d | 0d | 141 | 126.9 | تانیر |
| 247 | 1.3.4.2.2 | اجرای نهایی و بازرسی نصب سنسورها و تجهیزات فیلد | milestone | 0d | 2026-06-27 A | 2026-06-27 | 246, 216 | 90% | 0d | 7d |  |  |  | تانیر |
| 248 | 1.3.4.3 | **نصب سیستم Gas Detection** |  | 1d | 2026-06-27 A | 2026-06-27 |  | 80% | 0.2d | 7d |  | 141 | 112.8 |  |
| 249 | 1.3.4.3.1 | آماده سازی برای نصب سیستم Gas Detection |  | 1d | 2026-06-27 A | 2026-06-27 | 199, 216 | 80% | 0.2d | 7d | 0d | 141 | 112.8 | تانیر |
| 250 | 1.3.4.3.2 | اجرای نهایی و بازرسی نصب سیستم Gas Detection | milestone | 0d | 2026-06-27 A | 2026-06-27 | 249, 216 | 80% | 0d | 7d |  |  |  | تانیر |
| 251 | 1.3.4.4 | **نصب و پیکربندی سیستم کنترل مرکزی** |  | 1d | 2026-06-27 A | 2026-06-27 |  | 80% | 0.2d | 7d |  | 27 | 21.6 |  |
| 252 | 1.3.4.4.1 | آماده سازی برای نصب و پیکربندی سیستم کنترل مرکزی |  | 1d | 2026-06-27 A | 2026-06-27 | 148, 216 | 80% | 0.2d | 7d | 0d |  |  | تانیر |
| 253 | 1.3.4.4.2 | اجرای نهایی و بازرسی نصب و پیکربندی سیستم کنترل مرکزی | milestone | 0d | 2026-06-27 A | 2026-06-27 | 252, 216 | 80% | 0d | 7d |  | 27 | 21.6 | تانیر |
| 254 | 1.4 | **تست و راه اندازی (Commissioning)** |  | 5d | 2026-07-06 A | 2026-07-11 |  | 4% | 4.8d | 0d |  | 1,000 | 42 |  |
| 255 | 1.4.1 | **تست های پیش راه اندازی (Pre-Comm)** |  | 4d | 2026-07-06 A | 2026-07-09 |  | 50% | 2d | 1d |  | 84 | 42 |  |
| 256 | 1.4.1.1 | چک‌لیست‌های نصب تجهیزات |  | 4d | 2026-07-06 A | 2026-07-09 | 152 | 50% | 2d | 1d |  | 21 | 10.5 | تانیر |
| 257 | 1.4.1.2 | تست عایقی و پیوستگی کابل ها |  | 4d | 2026-07-06 A | 2026-07-09 | 152 | 50% | 2d | 0d |  | 42 | 21 | تانیر |
| 258 | 1.6.1.3 | تمیزکاری و فلاشینگ سیستم‌ها |  | 4d | 2026-07-06 A | 2026-07-09 | 152 | 50% | 2d | 1d |  | 21 | 10.5 | تانیر |
| 259 | 1.6.2 | **تست ترانسفورماتور** |  | 4d | 2026-07-06 | 2026-07-09 |  |  |  | 1d |  | 105 |  |  |
| 260 | 1.6.2.1 | تست نسبت تبدیل (TTR Test) |  | 4d | 2026-07-06 | 2026-07-09 | 152 |  |  | 1d |  | 21 |  | تانیر |
| 261 | 1.6.2.2 | تست عایقی (IR / Megger Test) |  | 4d | 2026-07-06 | 2026-07-09 | 152 |  |  | 1d |  | 21 |  | تانیر |
| 262 | 1.6.2.3 | تست روغن ترانس (BDV & DGA) |  | 4d | 2026-07-06 | 2026-07-09 | 152 |  |  | 1d |  | 21 |  | تانیر |
| 263 | 1.6.2.4 | تست عملکرد بی‌بار (No Load Test) |  | 4d | 2026-07-06 | 2026-07-09 | 152 |  |  | 1d |  | 21 |  | تانیر |
| 264 | 1.6.2.5 | تست تحت بار (Load Test) |  | 4d | 2026-07-06 | 2026-07-09 | 152 |  |  | 1d |  | 21 |  | تانیر |

| ID | WBS | Task | Duration | Start | Finish | Predecessors | Total slack | Cost | Text16 |
| --- | --- | --- | --- | --- | --- | --- | --- | --- | --- |
| 265 | 1.6.3 | **تست ژنراتور / مولد** | 4d | 2026-07-06 | 2026-07-09 |  | 1d | 148 |  |
| 266 | 1.6.3.1 | تست عایقی ژنراتور | 4d | 2026-07-06 | 2026-07-09 | 152 | 1d | 21 | تانیر |
| 267 | 1.6.3.2 | تست مدار تحریک | 4d | 2026-07-06 | 2026-07-09 | 152 | 1d | 21 | تانیر |
| 268 | 1.6.3.3 | تست سنکرونیزاسیون | 4d | 2026-07-06 | 2026-07-09 | 152 | 1d | 21 | تانیر |
| 269 | 1.6.3.4 | تست بی‌بار | 4d | 2026-07-06 | 2026-07-09 | 152 | 1d | 21 | تانیر |
| 270 | 1.6.3.5 | تست تحت بار کامل (Full Load Test) | 4d | 2026-07-06 | 2026-07-09 | 152 | 1d | 21 | تانیر |
| 271 | 1.6.3.6 | تست حفاظت‌ها (Protection Test) | 4d | 2026-07-06 | 2026-07-09 | 152 | 1d | 43 | تانیر |
| 272 | 1.6.4 | **تست رادیاتور و سیستم خنک‌کاری** | 4d | 2026-07-06 | 2026-07-09 |  | 1d | 105 |  |
| 273 | 1.6.4.1 | تست فشار (Pressure Test) | 4d | 2026-07-06 | 2026-07-09 | 152 | 1d | 21 | تانیر |
| 274 | 1.6.4.2 | تست نشتی (Leak Test) | 4d | 2026-07-06 | 2026-07-09 | 152 | 1d | 21 | تانیر |
| 275 | 1.6.4.3 | تست عملکرد فن‌ها | 4d | 2026-07-06 | 2026-07-09 | 152 | 1d | 21 | تانیر |
| 276 | 1.6.4.4 | تست گردش سیال خنک‌کننده | 4d | 2026-07-06 | 2026-07-09 | 152 | 1d | 21 | تانیر |
| 277 | 1.6.4.5 | تست عملکرد در بار نامی | 4d | 2026-07-06 | 2026-07-09 | 152 | 1d | 21 | تانیر |
| 278 | 1.6.5 | **تست سوئیچگیر (MV / LV Switchgear)** | 4d | 2026-07-06 | 2026-07-09 |  | 1d | 147 |  |
| 279 | 1.6.5.1 | تست عایقی (IR Test) | 4d | 2026-07-06 | 2026-07-09 | 152 | 1d | 21 | تانیر |
| 280 | 1.6.5.2 | تست عملکرد بریکرها | 4d | 2026-07-06 | 2026-07-09 | 152 | 1d | 21 | تانیر |
| 281 | 1.6.5.3 | تست اینترلاک‌ها | 4d | 2026-07-06 | 2026-07-09 | 152 | 1d | 21 | تانیر |
| 282 | 1.6.5.4 | تست رله‌های حفاظتی | 4d | 2026-07-06 | 2026-07-09 | 152 | 1d | 21 | تانیر |
| 283 | 1.6.5.5 | تست قطع و وصل تحت بار | 4d | 2026-07-06 | 2026-07-09 | 152 | 1d | 21 | تانیر |
| 284 | 1.6.5.6 | تست هماهنگی حفاظتی | 4d | 2026-07-06 | 2026-07-09 | 152 | 1d | 21 | تانیر |
| 285 | 1.6.5.7 | تست تابلو gcp و aux | 4d | 2026-07-06 | 2026-07-09 | 152 | 1d | 21 | تانیر |
| 286 | 1.6.6 | **تست سیستم کولینگ (Cooling System) سالن موتور** | 4d | 2026-07-06 | 2026-07-09 |  | 0d | 105 |  |
| 287 | 1.6.6.1 | تست پمپ‌های سیستم خنک‌کاری | 4d | 2026-07-06 | 2026-07-09 | 152 | 1d | 21 | تانیر |
| 288 | 1.6.6.2 | تست مدار لوله‌کشی خنک‌کاری | 4d | 2026-07-06 | 2026-07-09 | 152 | 0d | 21 | تانیر |
| 289 | 1.6.6.3 | تست عملکرد مبدل‌های حرارتی | 4d | 2026-07-06 | 2026-07-09 | 152 | 1d | 21 | تانیر |
| 290 | 1.6.6.4 | تست دبی و فشار سیستم | 4d | 2026-07-06 | 2026-07-09 | 152 | 1d | 21 | تانیر |
| 291 | 1.6.6.5 | تست عملکرد در شرایط عملیاتی | 4d | 2026-07-06 | 2026-07-09 | 152 | 1d | 21 | تانیر |

| ID | WBS | Task | Type | Duration | Start | Finish | Predecessors | Total slack | Cost | Text16 |
| --- | --- | --- | --- | --- | --- | --- | --- | --- | --- | --- |
| 292 | 1.6.7 | **تست‌های یکپارچه (Integrated Tests)** |  | 4d | 2026-07-06 | 2026-07-09 |  | 1d | 105 |  |
| 293 | 1.6.7.1 | تست بدون بار کل واحد (No Load Test Run) |  | 4d | 2026-07-06 | 2026-07-09 | 152 | 1d | 21 | تانیر |
| 294 | 1.6.7.2 | تست سنکرون کل سیستم |  | 4d | 2026-07-06 | 2026-07-09 | 152 | 1d | 21 | تانیر |
| 295 | 1.6.7.3 | تست Load Acceptance |  | 4d | 2026-07-06 | 2026-07-09 | 152 | 1d | 21 | تانیر |
| 296 | 1.6.7.4 | تست Trip و Emergency Shutdown |  | 4d | 2026-07-06 | 2026-07-09 | 152 | 1d | 21 | تانیر |
| 297 | 1.6.7.5 | تست عملکرد سیستم‌های کمکی |  | 4d | 2026-07-06 | 2026-07-09 | 152 | 1d | 21 | تانیر |
| 298 | 1.4.1.3 | **Cold Loop Test ابزاردقیق** |  | 1d | 2026-07-06 | 2026-07-06 |  | 4d | 42 |  |
| 299 | 1.4.1.3.1 | آماده سازی برای Cold Loop Test ابزاردقیق |  | 1d | 2026-07-06 | 2026-07-06 | 152 | 4d | 21 | تانیر |
| 300 | 1.4.1.3.2 | اجرای نهایی و بازرسی Cold Loop Test ابزاردقیق |  | 1d | 2026-07-06 | 2026-07-06 | 152 | 4d | 21 | تانیر |
| 301 | 1.4.2 | **راه اندازی (Commissioning)** |  | 1d | 2026-07-11 | 2026-07-11 |  | 0d | 159 |  |
| 302 | 1.4.2.1 | برق دار کردن تابلوهای داخلی |  | 1d | 2026-07-11 | 2026-07-11 | 257, 288 | 0d | 21 | تانیر |
| 303 | 1.4.2.2 | تست عملکردی سیستم سوخت رسانی |  | 1d | 2026-07-11 | 2026-07-11 | 302SS | 0d | 21 | تانیر |
| 304 | 1.4.2.3 | استارت اولیه مولد بدون بار |  | 1d | 2026-07-11 | 2026-07-11 | 302SS | 0d | 21 | تانیر |
| 305 | 1.4.2.4 | تست پارالل و سنکرون سازی |  | 1d | 2026-07-11 | 2026-07-11 | 302SS | 0d | 21 | تانیر |
| 306 | 1.4.2.5 | تست عملکردی زیر بار (Load Test) |  | 1d | 2026-07-11 | 2026-07-11 | 302SS | 0d | 33 | تانیر |
| 307 | 1.4.2.6 | تست نهایی سیستم Gas Detection |  | 1d | 2026-07-11 | 2026-07-11 | 302SS | 0d | 42 | تانیر |
| 308 | 1.5 | **تحویل و بهره برداری (Close-out)** |  | 30d | 2026-07-12 | 2026-08-15 |  | 0d | 15,000 |  |
| 309 | 1.5.1 | **بهره برداری آزمایشی** |  | 17d | 2026-07-12 | 2026-07-30 |  | 0d | 1,000 |  |
| 310 | 1.5.1.1 | دوره 72 ساعته تست مداوم |  | 1d | 2026-07-12 | 2026-07-12 | 254 | 0d | 1,000 | شرکت تأمین آب و انرژی هرمز ابدال |
| 311 | 1.5.1.2 | رفع نواقص احتمالی (Punch List) |  | 16d | 2026-07-13 | 2026-07-30 | 310 | 0d |  | تانیر |
| 312 | 1.5.2 | **مستندات و تحویل** |  | 13d | 2026-08-01 | 2026-08-15 |  | 0d | 14,000 |  |
| 313 | 1.5.2.1 | تهیه نقشه های As-Built |  | 2d | 2026-08-01 | 2026-08-02 | 311 | 0d | 2,000 | تانیر |
| 314 | 1.5.2.2 | آموزش تیم بهره بردار کارفرما |  | 3d | 2026-08-03 | 2026-08-05 | 313 | 0d | 1,000 | شرکت تأمین آب و انرژی هرمز ابدال |
| 315 | 1.5.2.3 | تحویل موقت (PAC) |  | 7d | 2026-08-06 | 2026-08-13 | 314 | 0d | 1,000 | شرکت افق تأمین انرژی پارس |
| 316 | 1.5.2.4 | شروع دوره بهره برداری (Operation) |  | 1d | 2026-08-15 | 2026-08-15 | 315 | 0d | 10,000 | شرکت افق تأمین انرژی پارس |
| 317 | 1.8 | پایان | milestone | 0d | 2026-08-15 | 2026-08-15 | 316, 297, 300, 291, 284, 277, 271, 94, 36, 50 | 0d |  |  |
